# AOA_TRIAL

Schedule from MS Project, 2020-10-13 to 2021-03-10.

## Calendars

- Standard: Mon-Fri 08:00-12:00, 13:00-17:00; Sat-Sun off.

## Resources

| Resource | Unit |
| --- | --- |
| by Level | ea. |
| Crew |  |

## Schedule

| ID | WBS | Task | Type | Duration | Start | Finish | Predecessors | Total slack | Free slack |
| --- | --- | --- | --- | --- | --- | --- | --- | --- | --- |
| 1 | 1 | **Three Span RC Bridge (Selinger 1980) https://spectrum.library.concordia.ca/978756/1/Bakry_PhD_S2014.pdf** |  | 106.77d | 2020-10-13 | 2021-03-10 |  | 0d |  |
| 2 | 1.1 | **Section 1** |  | 45.54d | 2020-10-13 | 2020-12-15 |  | 0d |  |
| 3 | 1.1.1 | Excavation 1 |  | 12.5d | 2020-10-13 | 2020-10-29 |  | 0d |  |
| 4 | 1.1.2 | Foundation 1 |  | 11.5d | 2020-10-29 | 2020-11-13 | 3 | 3.18d | 0d |
| 5 | 1.1.3 | Columns 1 |  | 12.95d | 2020-11-16 | 2020-12-02 | 4 | 3.18d | 0d |
| 6 | 1.1.4 | Beams 1 |  | 8.59d | 2020-12-02 | 2020-12-15 | 5 | 6.46d | 0d |
| 7 | 1.1.5 | Slabs 1 | milestone | 0d | 2020-12-15 | 2020-12-15 | 6 | 15.75d | 14.59d |
| 8 | 1.2 | **Section 2** |  | 63.44d | 2020-10-29 | 2021-01-26 |  | 0d |  |
| 9 | 1.2.1 | Excavation 2 |  | 15.63d | 2020-10-29 | 2020-11-20 | 3 | 0d |  |
| 10 | 1.2.2 | Foundation 2 |  | 12d | 2020-11-20 | 2020-12-08 | 9, 4 | 0d |  |
| 11 | 1.2.3 | Columns 2 |  | 10.71d | 2020-12-08 | 2020-12-22 | 10, 5 | 0d |  |
| 12 | 1.2.4 | Beams 2 |  | 9.29d | 2020-12-22 | 2021-01-05 | 11, 6 | 1.16d | 0d |
| 13 | 1.2.5 | Slabs 2 |  | 15.81d | 2021-01-05 | 2021-01-26 | 12, 7 | 1.16d |  |
| 14 | 1.3 | **Section 3** |  | 62.03d | 2020-11-20 | 2021-02-16 |  | 0d |  |
| 15 | 1.3.1 | Excavation 3 |  | 10.83d | 2020-11-20 | 2020-12-04 | 9 | 1.38d | 0d |
| 16 | 1.3.2 | Foundation 3 |  | 10.5d | 2020-12-08 | 2020-12-22 | 15, 10 | 0.21d |  |
| 17 | 1.3.3 | Columns 3 |  | 16.06d | 2020-12-22 | 2021-01-13 | 16, 11 | 0d |  |
| 18 | 1.3.4 | Beams 3 |  | 10.2d | 2021-01-13 | 2021-01-28 | 17, 12 | 0d |  |
| 19 | 1.3.5 | Slabs 3 |  | 13.06d | 2021-01-28 | 2021-02-16 | 18, 13 | 0d |  |
| 20 | 1.4 | **Section 4** |  | 67.81d | 2020-12-04 | 2021-03-10 |  | 0d |  |
| 21 | 1.4.1 | Excavation 4 |  | 16.66d | 2020-12-04 | 2020-12-29 | 15 | 4.03d | 0d |
| 22 | 1.4.2 | Foundation 4 |  | 9.98d | 2020-12-29 | 2021-01-12 | 21, 16 | 4.03d | 1.3d |
| 23 | 1.4.3 | Columns 4 |  | 12.45d | 2021-01-13 | 2021-02-01 | 22, 17 | 2.73d | 0d |
| 24 | 1.4.4 | Beams 4 |  | 8.08d | 2021-02-01 | 2021-02-11 | 23, 18 | 2.73d |  |
| 25 | 1.4.5 | Slabs 4 |  | 16.61d | 2021-02-16 | 2021-03-10 | 24, 19 | 0d |  |

| ID | WBS | Task | Duration | Start | Finish | Predecessors | Total slack | Free slack | Resources | Work |
| --- | --- | --- | --- | --- | --- | --- | --- | --- | --- | --- |
| 26 | 2 | **5-storey building** | 45d | 2020-10-13 | 2020-12-14 |  | 61.77d |  |  | 1025h |
| 27 | 2.1 | Structure | 25d | 2020-10-13 | 2020-11-16 |  | 61.77d | 0d | by Level [0.03 ea.]; Crew | 205h |
| 28 | 2.2 | Architecture | 25d | 2020-10-20 | 2020-11-23 | 27SS+1w | 61.77d | 0d | by Level [0.03 ea.]; Crew | 205h |
| 29 | 2.3 | MEP | 25d | 2020-10-27 | 2020-11-30 | 28SS+1w | 61.77d | 0d | by Level [0.03 ea.]; Crew | 205h |
| 30 | 2.4 | ID | 25d | 2020-11-03 | 2020-12-07 | 29SS+1w | 61.77d | 0d | by Level [0.03 ea.]; Crew | 205h |
| 31 | 2.5 | FF&E | 25d | 2020-11-10 | 2020-12-14 | 30SS+1w | 61.77d |  | by Level [0.03 ea.]; Crew | 205h |
